# 990227

Schedule from MS Project, 2020-04-11 to 2020-09-07.

## Calendars

- Standard: Mon-Sun 08:00-12:00, 13:00-17:00.

## Schedule

| ID | WBS | Task | Type | Duration | Start | Finish | Predecessors | Total slack | Free slack | Constraint | شروع | پایان |
| --- | --- | --- | --- | --- | --- | --- | --- | --- | --- | --- | --- | --- |
| 1 | 1 | **برنامه زمان بندی پایپینگ** |  | 150d | 2020-04-11 | 2020-09-07 |  | 0d |  |  | 99/1/23 | 99/6/17 |
| 2 | 1.1 | شروع | milestone | 0d | 2020-04-11 | 2020-04-11 |  | 150d |  | start no earlier than 2020-04-11 | 99/1/23 | 99/1/23 |
| 3 | 1.2 | تجهیزکارگاه | milestone | 0d | 2020-05-02 | 2020-05-02 |  | 79d | 0d | start no earlier than 2020-05-02 | 99/2/13 | 99/2/13 |
| 4 | 1.3 | **بخش ADD** |  | 60d | 2020-05-02 | 2020-06-30 |  | 69d |  |  | 99/2/13 | 99/4/10 |
| 5 | 1.3.1 | **خرید** |  | 13d | 2020-05-09 | 2020-05-21 |  | 108d |  |  | 99/2/20 | 99/3/1 |
| 6 | 1.3.1.1 | خرید متریال ساپورت و حمل |  | 13d | 2020-05-09 | 2020-05-21 |  | 108d | 0d | start no earlier than 2020-05-09 | 99/2/20 | 99/3/1 |
| 7 | 1.3.2 | **ساخت ساپورت** |  | 17d | 2020-05-09 | 2020-05-25 |  | 105d |  |  | 99/2/20 | 99/3/5 |
| 8 | 1.3.2.1 | ساخت ساپورت ساپورت |  | 14d | 2020-05-09 | 2020-05-22 | 6SS | 108d | 2d | finish no earlier than 2020-05-20 | 99/2/20 | 99/3/2 |
| 9 | 1.3.2.2 | جوشکاری ساپورت |  | 15d | 2020-05-11 | 2020-05-25 | 8SS | 105d |  | start no earlier than 2020-05-11 | 99/2/22 | 99/3/5 |
| 10 | 1.3.3 | **رنگ و سندبلاست** |  | 29d | 2020-05-02 | 2020-05-30 |  | 79d |  |  | 99/2/13 | 99/3/10 |
| 11 | 1.3.3.1 | **لوله** |  | 10d | 2020-05-02 | 2020-05-11 |  | 79d |  |  | 99/2/13 | 99/2/22 |
| 12 | 1.3.3.1.1 | بلاستینگ و رنگ آمیزی لایه 1 لوله ها |  | 10d | 2020-05-02 | 2020-05-11 | 3 | 79d | 0d |  | 99/2/13 | 99/2/22 |
| 13 | 1.3.3.2 | **ساپورت** |  | 12d | 2020-05-19 | 2020-05-30 |  | 100d |  |  | 99/2/30 | 99/3/10 |
| 14 | 1.3.3.2.1 | رفع پانچ B(REINSTATE) ساپورت |  | 5d | 2020-05-19 | 2020-05-23 |  | 107d |  | start no earlier than 2020-05-19 | 99/2/30 | 99/3/3 |
| 15 | 1.3.3.2.2 | بلاستینگ و رنگ آمیزی ساپورت |  | 4d | 2020-05-24 | 2020-05-27 |  | 100d | 0d | start no earlier than 2020-05-24 | 99/3/4 | 99/3/7 |
| 16 | 1.3.3.2.3 | رفع پانچ و تحویل دهی نهایی ساپورت |  | 3d | 2020-05-28 | 2020-05-30 | 15 | 100d | 22d | finish no earlier than 2020-05-23 | 99/3/8 | 99/3/10 |
| 17 | 1.3.4 | **اجرای پایپینگ** |  | 50d | 2020-05-12 | 2020-06-30 |  | 69d |  |  | 99/2/23 | 99/4/10 |
| 18 | 1.3.4.1 | تا مرحله فیتاپ |  | 40d | 2020-05-12 | 2020-06-20 | 12 | 79d |  | finish no earlier than 2020-06-14 | 99/2/23 | 99/3/31 |
| 19 | 1.3.4.2 | تحویل اسلیپر | milestone | 0d | 2020-06-09 | 2020-06-09 |  | 69d | 0d | start no earlier than 2020-06-09 | 99/3/20 | 99/3/20 |
| 20 | 1.3.4.3 | نصب پایپینگ در موقعیت |  | 10d | 2020-06-09 | 2020-06-18 | 19 | 69d | 0d | start no earlier than 2020-06-05 | 99/3/20 | 99/3/29 |
| 21 | 1.3.4.4 | جوشکاری پایپینگ |  | 10d | 2020-06-09 | 2020-06-18 | 20SS | 69d | 0d | start no earlier than 2020-06-06 | 99/3/20 | 99/3/29 |
| 22 | 1.3.4.5 | نصب و تنظیم ساپورت در موقعیت |  | 9d | 2020-06-19 | 2020-06-27 | 21, 16SS | 69d | 0d | start no earlier than 2020-06-06 | 99/3/30 | 99/4/7 |
| 23 | 1.3.4.6 | جوشکاری و نصب ساپورت در محل |  | 10d | 2020-06-19 | 2020-06-28 | 22SS | 69d | 0d | start no earlier than 2020-06-06 | 99/3/30 | 99/4/8 |
| 24 | 1.3.4.7 | تست NDT |  | 10d | 2020-06-19 | 2020-06-28 | 23SS | 69d | 0d | start no earlier than 2020-06-15 | 99/3/30 | 99/4/8 |
| 25 | 1.3.4.8 | رفع پانچ A و LINE CHECK |  | 10d | 2020-06-19 | 2020-06-28 | 24SS | 69d | 0d | start no earlier than 2020-06-16 | 99/3/30 | 99/4/8 |
| 26 | 1.3.4.9 | هیدروتست،فلاشینگ و DRYING |  | 10d | 2020-06-19 | 2020-06-28 | 25SS | 69d | 0d |  | 99/3/30 | 99/4/8 |
| 27 | 1.3.4.10 | REINSTATEMENT |  | 3d | 2020-06-19 | 2020-06-21 | 26SS | 69d | 0d |  | 99/3/30 | 99/4/1 |
| 28 | 1.3.4.11 | تاچ آپ رنگ لوله ها بعد از نصب |  | 2d | 2020-06-22 | 2020-06-23 | 27 | 69d | 0d |  | 99/4/2 | 99/4/3 |
| 29 | 1.3.4.12 | رنگ آمیزی لایه های میانی و نهایی |  | 5d | 2020-06-24 | 2020-06-28 | 28 | 69d | 0d |  | 99/4/4 | 99/4/8 |
| 30 | 1.3.4.13 | رفع پانچ B |  | 2d | 2020-06-29 | 2020-06-30 | 29 | 69d | 0d |  | 99/4/9 | 99/4/10 |
| 31 | 1.3.5 | تکمیل مدارک و مستندات |  | 2d | 2020-06-29 | 2020-06-30 | 30SS | 69d |  |  | 99/4/9 | 99/4/10 |

| ID | WBS | Task | Type | Duration | Start | Finish | Predecessors | Total slack | Free slack | Constraint | شروع | پایان |
| --- | --- | --- | --- | --- | --- | --- | --- | --- | --- | --- | --- | --- |
| 32 | 1.4 | **بخش BSO** |  | 109d | 2020-05-21 | 2020-09-06 |  | 1d |  |  | 99/3/1 | 99/6/16 |
| 33 | 1.4.1 | **خرید** |  | 15d | 2020-05-21 | 2020-06-04 |  | 10d |  |  | 99/3/1 | 99/3/15 |
| 34 | 1.4.1.1 | خرید متریال ساپورت و حمل |  | 15d | 2020-05-21 | 2020-06-04 |  | 10d | 0d | start no earlier than 2020-05-21 | 99/3/1 | 99/3/15 |
| 35 | 1.4.2 | **ساخت ساپورت** |  | 20d | 2020-05-21 | 2020-06-09 |  | 10d |  |  | 99/3/1 | 99/3/20 |
| 36 | 1.4.2.1 | ساخت ساپورت ساپورت |  | 10d | 2020-05-21 | 2020-05-30 | 34SS | 10d | 0d |  | 99/3/1 | 99/3/10 |
| 37 | 1.4.2.2 | جوشکاری ساپورت |  | 10d | 2020-05-31 | 2020-06-09 | 36 | 10d | 0d |  | 99/3/11 | 99/3/20 |
| 38 | 1.4.3 | **رنگ و سندبلاست** |  | 22d | 2020-05-28 | 2020-06-18 |  | 11d |  |  | 99/3/8 | 99/3/29 |
| 39 | 1.4.3.1 | **لوله** |  | 3d | 2020-05-28 | 2020-05-30 |  | 30d |  |  | 99/3/8 | 99/3/10 |
| 40 | 1.4.3.1.1 | بلاستینگ و رنگ آمیزی لایه 1 لوله ها |  | 3d | 2020-05-28 | 2020-05-30 |  | 30d | 0d | start no earlier than 2020-05-28 | 99/3/8 | 99/3/10 |
| 41 | 1.4.3.2 | **ساپورت** |  | 9d | 2020-06-10 | 2020-06-18 |  | 10d |  |  | 99/3/21 | 99/3/29 |
| 42 | 1.4.3.2.1 | رفع پانچ B(REINSTATE) ساپورت |  | 3d | 2020-06-10 | 2020-06-12 | 37 | 10d | 0d |  | 99/3/21 | 99/3/23 |
| 43 | 1.4.3.2.2 | بلاستینگ و رنگ آمیزی ساپورت |  | 2d | 2020-06-13 | 2020-06-14 | 42 | 10d | 0d |  | 99/3/24 | 99/3/25 |
| 44 | 1.4.3.2.3 | رفع پانچ و تحویل دهی نهایی ساپورت |  | 4d | 2020-06-15 | 2020-06-18 | 43 | 10d | 4d |  | 99/3/26 | 99/3/29 |
| 45 | 1.4.4 | **اجرای پایپینگ** |  | 99d | 2020-05-31 | 2020-09-06 |  | 1d |  |  | 99/3/11 | 99/6/16 |
| 46 | 1.4.4.1 | تا مرحله فیتاپ |  | 70d | 2020-05-31 | 2020-08-08 | 40 | 30d |  |  | 99/3/11 | 99/5/18 |
| 47 | 1.4.4.2 | تحویل اسلیپر | milestone | 0d | 2020-06-19 | 2020-06-19 |  | 1d | 0d | start no earlier than 2020-06-19 | 99/3/30 | 99/3/30 |
| 48 | 1.4.4.3 | نصب پایپینگ در موقعیت |  | 60d | 2020-06-19 | 2020-08-17 | 47 | 1d | 0d |  | 99/3/30 | 99/5/27 |
| 49 | 1.4.4.4 | جوشکاری پایپینگ |  | 75d | 2020-06-19 | 2020-09-01 | 48SS | 1d | 0d |  | 99/3/30 | 99/6/11 |
| 50 | 1.4.4.5 | نصب و تنظیم ساپورت در موقعیت |  | 75d | 2020-06-19 | 2020-09-01 | 49SS, 44SS | 6d | 0d |  | 99/3/30 | 99/6/11 |
| 51 | 1.4.4.6 | جوشکاری و نصب ساپورت در محل |  | 75d | 2020-06-19 | 2020-09-01 | 50SS | 6d |  |  | 99/3/30 | 99/6/11 |
| 52 | 1.4.4.7 | تست NDT |  | 75d | 2020-06-19 | 2020-09-01 | 49SS | 1d | 0d |  | 99/3/30 | 99/6/11 |
| 53 | 1.4.4.8 | رفع پانچ A و LINE CHECK |  | 65d | 2020-06-19 | 2020-08-22 | 52SS | 1d | 0d |  | 99/3/30 | 99/6/1 |
| 54 | 1.4.4.9 | هیدروتست،فلاشینگ و DRYING |  | 65d | 2020-06-19 | 2020-08-22 | 53SS | 1d | 0d |  | 99/3/30 | 99/6/1 |
| 55 | 1.4.4.10 | REINSTATEMENT |  | 65d | 2020-06-19 | 2020-08-22 | 54SS | 1d | 0d |  | 99/3/30 | 99/6/1 |
| 56 | 1.4.4.11 | تاچ آپ رنگ لوله ها بعد از نصب |  | 5d | 2020-08-23 | 2020-08-27 | 55 | 1d | 0d |  | 99/6/2 | 99/6/6 |
| 57 | 1.4.4.12 | رنگ آمیزی لایه های میانی و نهایی |  | 5d | 2020-08-28 | 2020-09-01 | 56 | 1d | 0d |  | 99/6/7 | 99/6/11 |
| 58 | 1.4.4.13 | رفع پانچ B |  | 5d | 2020-09-02 | 2020-09-06 | 57 | 1d | 0d |  | 99/6/12 | 99/6/16 |
| 59 | 1.4.5 | تکمیل مدارک و مستندات |  | 1d | 2020-09-02 | 2020-09-02 | 58SS | 5d |  |  | 99/6/12 | 99/6/12 |

| ID | WBS | Task | Type | Duration | Start | Finish | Predecessors | Total slack | Free slack | Constraint | شروع | پایان |
| --- | --- | --- | --- | --- | --- | --- | --- | --- | --- | --- | --- | --- |
| 60 | 1.5 | **بخش GSO** |  | 72d | 2020-05-21 | 2020-07-31 |  | 38d |  |  | 99/3/1 | 99/5/10 |
| 61 | 1.5.1 | **خرید** |  | 15d | 2020-05-21 | 2020-06-04 |  | 53d |  |  | 99/3/1 | 99/3/15 |
| 62 | 1.5.1.1 | خرید متریال ساپورت و حمل |  | 15d | 2020-05-21 | 2020-06-04 |  | 53d | 0d | start no earlier than 2020-05-21 | 99/3/1 | 99/3/15 |
| 63 | 1.5.2 | **ساخت ساپورت** |  | 20d | 2020-05-21 | 2020-06-09 |  | 53d |  |  | 99/3/1 | 99/3/20 |
| 64 | 1.5.2.1 | ساخت ساپورت ساپورت |  | 10d | 2020-05-21 | 2020-05-30 | 62SS | 53d | 0d |  | 99/3/1 | 99/3/10 |
| 65 | 1.5.2.2 | جوشکاری ساپورت |  | 10d | 2020-05-31 | 2020-06-09 | 64 | 53d | 0d |  | 99/3/11 | 99/3/20 |
| 66 | 1.5.3 | **رنگ و سندبلاست** |  | 28d | 2020-05-22 | 2020-06-18 |  | 72d |  |  | 99/3/2 | 99/3/29 |
| 67 | 1.5.3.1 | **لوله** |  | 3d | 2020-05-22 | 2020-05-24 |  | 101d |  |  | 99/3/2 | 99/3/4 |
| 68 | 1.5.3.1.1 | بلاستینگ و رنگ آمیزی لایه 1 لوله ها |  | 3d | 2020-05-22 | 2020-05-24 |  | 101d | 0d | start no earlier than 2020-05-22 | 99/3/2 | 99/3/4 |
| 69 | 1.5.3.2 | **ساپورت** |  | 9d | 2020-06-10 | 2020-06-18 |  | 53d |  |  | 99/3/21 | 99/3/29 |
| 70 | 1.5.3.2.1 | رفع پانچ B(REINSTATE) ساپورت |  | 3d | 2020-06-10 | 2020-06-12 | 65 | 53d | 0d |  | 99/3/21 | 99/3/23 |
| 71 | 1.5.3.2.2 | بلاستینگ و رنگ آمیزی ساپورت |  | 2d | 2020-06-13 | 2020-06-14 | 70 | 53d | 0d |  | 99/3/24 | 99/3/25 |
| 72 | 1.5.3.2.3 | رفع پانچ و تحویل دهی نهایی ساپورت |  | 4d | 2020-06-15 | 2020-06-18 | 71 | 53d | 15d |  | 99/3/26 | 99/3/29 |
| 73 | 1.5.4 | **اجرای پایپینگ** |  | 68d | 2020-05-25 | 2020-07-31 |  | 38d |  |  | 99/3/5 | 99/5/10 |
| 74 | 1.5.4.1 | تا مرحله فیتاپ |  | 5d | 2020-05-25 | 2020-05-29 | 68 | 101d |  |  | 99/3/5 | 99/3/9 |
| 75 | 1.5.4.2 | تحویل اسلیپر | milestone | 0d | 2020-06-19 | 2020-06-19 |  | 38d | 0d | start no earlier than 2020-06-19 | 99/3/30 | 99/3/30 |
| 76 | 1.5.4.3 | نصب پایپینگ در موقعیت |  | 5d | 2020-06-19 | 2020-06-23 | 75 | 38d | 0d |  | 99/3/30 | 99/4/3 |
| 77 | 1.5.4.4 | جوشکاری پایپینگ |  | 6d | 2020-06-24 | 2020-06-29 | 76 | 38d | 0d |  | 99/4/4 | 99/4/9 |
| 78 | 1.5.4.5 | نصب و تنظیم ساپورت در موقعیت |  | 4d | 2020-06-30 | 2020-07-03 | 72SS, 77 | 38d | 0d |  | 99/4/10 | 99/4/13 |
| 79 | 1.5.4.6 | جوشکاری و نصب ساپورت در محل |  | 4d | 2020-07-04 | 2020-07-07 | 78 | 38d | 0d |  | 99/4/14 | 99/4/17 |
| 80 | 1.5.4.7 | تست NDT |  | 2d | 2020-07-08 | 2020-07-09 | 79 | 38d | 0d |  | 99/4/18 | 99/4/19 |
| 81 | 1.5.4.8 | رفع پانچ A و LINE CHECK |  | 2d | 2020-07-10 | 2020-07-11 | 80 | 38d | 0d |  | 99/4/20 | 99/4/21 |
| 82 | 1.5.4.9 | هیدروتست،فلاشینگ و DRYING |  | 10d | 2020-07-12 | 2020-07-21 | 81 | 38d | 0d |  | 99/4/22 | 99/4/31 |
| 83 | 1.5.4.10 | REINSTATEMENT |  | 2d | 2020-07-22 | 2020-07-23 | 82 | 38d | 0d |  | 99/5/1 | 99/5/2 |
| 84 | 1.5.4.11 | تاچ آپ رنگ لوله ها بعد از نصب |  | 2d | 2020-07-24 | 2020-07-25 | 83 | 38d | 0d |  | 99/5/3 | 99/5/4 |
| 85 | 1.5.4.12 | رنگ آمیزی لایه های میانی و نهایی |  | 5d | 2020-07-26 | 2020-07-30 | 84 | 38d | 0d |  | 99/5/5 | 99/5/9 |
| 86 | 1.5.4.13 | رفع پانچ B |  | 1d | 2020-07-31 | 2020-07-31 | 85 | 38d | 0d |  | 99/5/10 | 99/5/10 |
| 87 | 1.5.5 | تکمیل مدارک و مستندات |  | 1d | 2020-07-31 | 2020-07-31 | 86SS | 38d |  |  | 99/5/10 | 99/5/10 |

| ID | WBS | Task | Type | Duration | Start | Finish | Predecessors | Total slack | Free slack | Constraint | شروع | پایان |
| --- | --- | --- | --- | --- | --- | --- | --- | --- | --- | --- | --- | --- |
| 88 | 1.6 | **بخش HOR** |  | 63d | 2020-05-22 | 2020-07-23 |  | 46d |  |  | 99/3/2 | 99/5/2 |
| 89 | 1.6.1 | **خرید** |  | 15d | 2020-05-28 | 2020-06-11 |  | 46d |  |  | 99/3/8 | 99/3/22 |
| 90 | 1.6.1.1 | خرید متریال ساپورت و حمل |  | 15d | 2020-05-28 | 2020-06-11 |  | 46d | 0d | start no earlier than 2020-05-28 | 99/3/8 | 99/3/22 |
| 91 | 1.6.2 | **ساخت ساپورت** |  | 20d | 2020-05-28 | 2020-06-16 |  | 46d |  |  | 99/3/8 | 99/3/27 |
| 92 | 1.6.2.1 | ساخت ساپورت ساپورت |  | 10d | 2020-05-28 | 2020-06-06 | 90SS | 46d | 0d |  | 99/3/8 | 99/3/17 |
| 93 | 1.6.2.2 | جوشکاری ساپورت |  | 10d | 2020-06-07 | 2020-06-16 | 92 | 46d | 0d |  | 99/3/18 | 99/3/27 |
| 94 | 1.6.3 | **رنگ و سندبلاست** |  | 35d | 2020-05-22 | 2020-06-25 |  | 69d |  |  | 99/3/2 | 99/4/5 |
| 95 | 1.6.3.1 | **لوله** |  | 3d | 2020-05-22 | 2020-05-24 |  | 101d |  |  | 99/3/2 | 99/3/4 |
| 96 | 1.6.3.1.1 | بلاستینگ و رنگ آمیزی لایه 1 لوله ها |  | 3d | 2020-05-22 | 2020-05-24 |  | 101d | 0d | start no earlier than 2020-05-22 | 99/3/2 | 99/3/4 |
| 97 | 1.6.3.2 | **ساپورت** |  | 9d | 2020-06-17 | 2020-06-25 |  | 46d |  |  | 99/3/28 | 99/4/5 |
| 98 | 1.6.3.2.1 | رفع پانچ B(REINSTATE) ساپورت |  | 3d | 2020-06-17 | 2020-06-19 | 93 | 46d | 0d |  | 99/3/28 | 99/3/30 |
| 99 | 1.6.3.2.2 | بلاستینگ و رنگ آمیزی ساپورت |  | 2d | 2020-06-20 | 2020-06-21 | 98 | 46d | 0d |  | 99/3/31 | 99/4/1 |
| 100 | 1.6.3.2.3 | رفع پانچ و تحویل دهی نهایی ساپورت |  | 4d | 2020-06-22 | 2020-06-25 | 99 | 46d | 0d |  | 99/4/2 | 99/4/5 |
| 101 | 1.6.4 | **اجرای پایپینگ** |  | 60d | 2020-05-25 | 2020-07-23 |  | 46d |  |  | 99/3/5 | 99/5/2 |
| 102 | 1.6.4.1 | تا مرحله فیتاپ |  | 5d | 2020-05-25 | 2020-05-29 | 96 | 101d |  |  | 99/3/5 | 99/3/9 |
| 103 | 1.6.4.2 | تحویل اسلیپر | milestone | 0d | 2020-06-09 | 2020-06-09 |  | 48d | 0d | start no earlier than 2020-06-09 | 99/3/20 | 99/3/20 |
| 104 | 1.6.4.3 | نصب پایپینگ در موقعیت |  | 5d | 2020-06-09 | 2020-06-13 | 103 | 48d | 0d |  | 99/3/20 | 99/3/24 |
| 105 | 1.6.4.4 | جوشکاری پایپینگ |  | 6d | 2020-06-14 | 2020-06-19 | 104 | 48d | 2d |  | 99/3/25 | 99/3/30 |
| 106 | 1.6.4.5 | نصب و تنظیم ساپورت در موقعیت |  | 4d | 2020-06-22 | 2020-06-25 | 100SS, 105 | 46d | 0d |  | 99/4/2 | 99/4/5 |
| 107 | 1.6.4.6 | جوشکاری و نصب ساپورت در محل |  | 4d | 2020-06-26 | 2020-06-29 | 106 | 46d | 0d |  | 99/4/6 | 99/4/9 |
| 108 | 1.6.4.7 | تست NDT |  | 2d | 2020-06-30 | 2020-07-01 | 107 | 46d | 0d |  | 99/4/10 | 99/4/11 |
| 109 | 1.6.4.8 | رفع پانچ A و LINE CHECK |  | 2d | 2020-07-02 | 2020-07-03 | 108 | 46d | 0d |  | 99/4/12 | 99/4/13 |
| 110 | 1.6.4.9 | هیدروتست،فلاشینگ و DRYING |  | 10d | 2020-07-04 | 2020-07-13 | 109 | 46d | 0d |  | 99/4/14 | 99/4/23 |
| 111 | 1.6.4.10 | REINSTATEMENT |  | 2d | 2020-07-14 | 2020-07-15 | 110 | 46d | 0d |  | 99/4/24 | 99/4/25 |
| 112 | 1.6.4.11 | تاچ آپ رنگ لوله ها بعد از نصب |  | 2d | 2020-07-16 | 2020-07-17 | 111 | 46d | 0d |  | 99/4/26 | 99/4/27 |
| 113 | 1.6.4.12 | رنگ آمیزی لایه های میانی و نهایی |  | 5d | 2020-07-18 | 2020-07-22 | 112 | 46d | 0d |  | 99/4/28 | 99/5/1 |
| 114 | 1.6.4.13 | رفع پانچ B |  | 1d | 2020-07-23 | 2020-07-23 | 113 | 46d | 0d |  | 99/5/2 | 99/5/2 |
| 115 | 1.6.5 | تکمیل مدارک و مستندات |  | 1d | 2020-07-23 | 2020-07-23 | 114SS | 46d |  |  | 99/5/2 | 99/5/2 |

| ID | WBS | Task | Type | Duration | Start | Finish | Predecessors | Total slack | Free slack | Constraint | شروع | پایان |
| --- | --- | --- | --- | --- | --- | --- | --- | --- | --- | --- | --- | --- |
| 116 | 1.7 | **بخش HOS** |  | 66d | 2020-05-28 | 2020-08-01 |  | 37d |  |  | 99/3/8 | 99/5/11 |
| 117 | 1.7.1 | **خرید** |  | 15d | 2020-05-28 | 2020-06-11 |  | 46d |  |  | 99/3/8 | 99/3/22 |
| 118 | 1.7.1.1 | خرید متریال ساپورت و حمل |  | 15d | 2020-05-28 | 2020-06-11 |  | 46d | 0d | start no earlier than 2020-05-28 | 99/3/8 | 99/3/22 |
| 119 | 1.7.2 | **ساخت ساپورت** |  | 20d | 2020-05-28 | 2020-06-16 |  | 46d |  |  | 99/3/8 | 99/3/27 |
| 120 | 1.7.2.1 | ساخت ساپورت ساپورت |  | 10d | 2020-05-28 | 2020-06-06 | 118SS | 46d | 0d |  | 99/3/8 | 99/3/17 |
| 121 | 1.7.2.2 | جوشکاری ساپورت |  | 10d | 2020-06-07 | 2020-06-16 | 120 | 46d | 0d |  | 99/3/18 | 99/3/27 |
| 122 | 1.7.3 | **رنگ و سندبلاست** |  | 19d | 2020-06-07 | 2020-06-25 |  | 56d |  |  | 99/3/18 | 99/4/5 |
| 123 | 1.7.3.1 | **لوله** |  | 3d | 2020-06-07 | 2020-06-09 |  | 85d |  |  | 99/3/18 | 99/3/20 |
| 124 | 1.7.3.1.1 | بلاستینگ و رنگ آمیزی لایه 1 لوله ها |  | 3d | 2020-06-07 | 2020-06-09 |  | 85d | 0d | start no earlier than 2020-06-07 | 99/3/18 | 99/3/20 |
| 125 | 1.7.3.2 | **ساپورت** |  | 9d | 2020-06-17 | 2020-06-25 |  | 46d |  |  | 99/3/28 | 99/4/5 |
| 126 | 1.7.3.2.1 | رفع پانچ B(REINSTATE) ساپورت |  | 3d | 2020-06-17 | 2020-06-19 | 121 | 46d | 0d |  | 99/3/28 | 99/3/30 |
| 127 | 1.7.3.2.2 | بلاستینگ و رنگ آمیزی ساپورت |  | 2d | 2020-06-20 | 2020-06-21 | 126 | 46d | 0d |  | 99/3/31 | 99/4/1 |
| 128 | 1.7.3.2.3 | رفع پانچ و تحویل دهی نهایی ساپورت |  | 4d | 2020-06-22 | 2020-06-25 | 127 | 46d | 9d |  | 99/4/2 | 99/4/5 |
| 129 | 1.7.4 | **اجرای پایپینگ** |  | 53d | 2020-06-10 | 2020-08-01 |  | 37d |  |  | 99/3/21 | 99/5/11 |
| 130 | 1.7.4.1 | تا مرحله فیتاپ |  | 5d | 2020-06-10 | 2020-06-14 | 124 | 85d |  |  | 99/3/21 | 99/3/25 |
| 131 | 1.7.4.2 | تحویل اسلیپر | milestone | 0d | 2020-06-20 | 2020-06-20 |  | 37d | 0d | start no earlier than 2020-06-20 | 99/3/31 | 99/3/31 |
| 132 | 1.7.4.3 | نصب پایپینگ در موقعیت |  | 5d | 2020-06-20 | 2020-06-24 | 131 | 37d | 0d |  | 99/3/31 | 99/4/4 |
| 133 | 1.7.4.4 | جوشکاری پایپینگ |  | 6d | 2020-06-25 | 2020-06-30 | 132 | 37d | 0d |  | 99/4/5 | 99/4/10 |
| 134 | 1.7.4.5 | نصب و تنظیم ساپورت در موقعیت |  | 4d | 2020-07-01 | 2020-07-04 | 128SS, 133 | 37d | 0d |  | 99/4/11 | 99/4/14 |
| 135 | 1.7.4.6 | جوشکاری و نصب ساپورت در محل |  | 4d | 2020-07-05 | 2020-07-08 | 134 | 37d | 0d |  | 99/4/15 | 99/4/18 |
| 136 | 1.7.4.7 | تست NDT |  | 2d | 2020-07-09 | 2020-07-10 | 135 | 37d | 0d |  | 99/4/19 | 99/4/20 |
| 137 | 1.7.4.8 | رفع پانچ A و LINE CHECK |  | 2d | 2020-07-11 | 2020-07-12 | 136 | 37d | 0d |  | 99/4/21 | 99/4/22 |
| 138 | 1.7.4.9 | هیدروتست،فلاشینگ و DRYING |  | 10d | 2020-07-13 | 2020-07-22 | 137 | 37d | 0d |  | 99/4/23 | 99/5/1 |
| 139 | 1.7.4.10 | REINSTATEMENT |  | 2d | 2020-07-23 | 2020-07-24 | 138 | 37d | 0d |  | 99/5/2 | 99/5/3 |
| 140 | 1.7.4.11 | تاچ آپ رنگ لوله ها بعد از نصب |  | 2d | 2020-07-25 | 2020-07-26 | 139 | 37d | 0d |  | 99/5/4 | 99/5/5 |
| 141 | 1.7.4.12 | رنگ آمیزی لایه های میانی و نهایی |  | 5d | 2020-07-27 | 2020-07-31 | 140 | 37d | 0d |  | 99/5/6 | 99/5/10 |
| 142 | 1.7.4.13 | رفع پانچ B |  | 1d | 2020-08-01 | 2020-08-01 | 141 | 37d | 0d |  | 99/5/11 | 99/5/11 |
| 143 | 1.7.5 | تکمیل مدارک و مستندات |  | 1d | 2020-08-01 | 2020-08-01 | 142SS | 37d |  |  | 99/5/11 | 99/5/11 |

| ID | WBS | Task | Type | Duration | Start | Finish | Predecessors | Total slack | Free slack | Constraint | شروع | پایان |
| --- | --- | --- | --- | --- | --- | --- | --- | --- | --- | --- | --- | --- |
| 144 | 1.8 | **بخش ISA** |  | 71d | 2020-06-02 | 2020-08-11 |  | 27d |  |  | 99/3/13 | 99/5/21 |
| 145 | 1.8.1 | **خرید** |  | 15d | 2020-06-10 | 2020-06-24 |  | 27d |  |  | 99/3/21 | 99/4/4 |
| 146 | 1.8.1.1 | خرید متریال ساپورت و حمل |  | 15d | 2020-06-10 | 2020-06-24 |  | 27d | 0d | start no earlier than 2020-06-10 | 99/3/21 | 99/4/4 |
| 147 | 1.8.2 | **رنگ و سندبلاست** |  | 34d | 2020-06-02 | 2020-07-05 |  | 55d |  |  | 99/3/13 | 99/4/15 |
| 148 | 1.8.2.1 | **لوله** |  | 10d | 2020-06-02 | 2020-06-11 |  | 83d |  |  | 99/3/13 | 99/3/22 |
| 149 | 1.8.2.1.1 | بلاستینگ و رنگ آمیزی لایه 1 لوله ها |  | 10d | 2020-06-02 | 2020-06-11 |  | 83d | 0d | start no earlier than 2020-06-02 | 99/3/13 | 99/3/22 |
| 150 | 1.8.2.2 | **ساپورت** |  | 6d | 2020-06-30 | 2020-07-05 |  | 27d |  |  | 99/4/10 | 99/4/15 |
| 151 | 1.8.2.2.1 | بلاستینگ و رنگ آمیزی ساپورت |  | 3d | 2020-07-03 | 2020-07-05 | 152, 155 | 27d | 0d |  | 99/4/13 | 99/4/15 |
| 152 | 1.8.2.2.2 | رفع پانچ B(REINSTATE) ساپورت |  | 3d | 2020-06-30 | 2020-07-02 | 155 | 27d | 0d |  | 99/4/10 | 99/4/12 |
| 153 | 1.8.3 | **ساخت ساپورت** |  | 15d | 2020-06-25 | 2020-07-09 |  | 27d |  |  | 99/4/5 | 99/4/19 |
| 154 | 1.8.3.1 | ساخت ساپورت ساپورت |  | 3d | 2020-06-25 | 2020-06-27 | 146 | 27d | 0d |  | 99/4/5 | 99/4/7 |
| 155 | 1.8.3.2 | جوشکاری ساپورت |  | 2d | 2020-06-28 | 2020-06-29 | 154 | 27d | 0d |  | 99/4/8 | 99/4/9 |
| 156 | 1.8.3.3 | رفع پانچ و تحویل دهی نهایی ساپورت |  | 4d | 2020-07-06 | 2020-07-09 | 151 | 27d | 0d |  | 99/4/16 | 99/4/19 |
| 157 | 1.8.4 | **اجرای پایپینگ** |  | 60d | 2020-06-12 | 2020-08-10 |  | 28d |  |  | 99/3/23 | 99/5/20 |
| 158 | 1.8.4.1 | تا مرحله فیتاپ |  | 5d | 2020-06-12 | 2020-06-16 | 149 | 83d |  |  | 99/3/23 | 99/3/27 |
| 159 | 1.8.4.2 | تحویل اسلیپر | milestone | 0d | 2020-06-21 | 2020-06-21 |  | 35d | 0d | start no earlier than 2020-06-21 | 99/4/1 | 99/4/1 |
| 160 | 1.8.4.3 | نصب پایپینگ در موقعیت |  | 5d | 2020-06-21 | 2020-06-25 | 159 | 35d | 0d |  | 99/4/1 | 99/4/5 |
| 161 | 1.8.4.4 | جوشکاری پایپینگ |  | 6d | 2020-06-26 | 2020-07-01 | 160 | 35d | 8d |  | 99/4/6 | 99/4/11 |
| 162 | 1.8.4.5 | نصب و تنظیم ساپورت در موقعیت |  | 4d | 2020-07-10 | 2020-07-13 | 156, 161 | 27d | 0d |  | 99/4/20 | 99/4/23 |
| 163 | 1.8.4.6 | جوشکاری و نصب ساپورت در محل |  | 4d | 2020-07-14 | 2020-07-17 | 162 | 27d | 0d |  | 99/4/24 | 99/4/27 |
| 164 | 1.8.4.7 | تست NDT |  | 2d | 2020-07-18 | 2020-07-19 | 163 | 27d | 0d |  | 99/4/28 | 99/4/29 |
| 165 | 1.8.4.8 | رفع پانچ A و LINE CHECK |  | 2d | 2020-07-20 | 2020-07-21 | 164 | 27d | 0d |  | 99/4/30 | 99/4/31 |
| 166 | 1.8.4.9 | هیدروتست،فلاشینگ و DRYING |  | 10d | 2020-07-22 | 2020-07-31 | 165 | 27d | 0d |  | 99/5/1 | 99/5/10 |
| 167 | 1.8.4.10 | REINSTATEMENT |  | 2d | 2020-08-01 | 2020-08-02 | 166 | 27d | 0d |  | 99/5/11 | 99/5/12 |
| 168 | 1.8.4.11 | تاچ آپ رنگ لوله ها بعد از نصب |  | 2d | 2020-08-03 | 2020-08-04 | 167 | 27d | 0d |  | 99/5/13 | 99/5/14 |
| 169 | 1.8.4.12 | رنگ آمیزی لایه های میانی و نهایی |  | 5d | 2020-08-05 | 2020-08-09 | 168 | 27d | 0d |  | 99/5/15 | 99/5/19 |
| 170 | 1.8.4.13 | رفع پانچ B |  | 1d | 2020-08-10 | 2020-08-10 | 169 | 27d | 0d |  | 99/5/20 | 99/5/20 |
| 171 | 1.8.5 | تکمیل مدارک و مستندات |  | 1d | 2020-08-11 | 2020-08-11 | 170 | 27d |  |  | 99/5/21 | 99/5/21 |

| ID | WBS | Task | Type | Duration | Start | Finish | Predecessors | Total slack | Free slack | Constraint | شروع | پایان |
| --- | --- | --- | --- | --- | --- | --- | --- | --- | --- | --- | --- | --- |
| 172 | 1.9 | **بخش LPC** |  | 64d | 2020-06-10 | 2020-08-12 |  | 26d |  |  | 99/3/21 | 99/5/22 |
| 173 | 1.9.1 | **خرید** |  | 15d | 2020-06-10 | 2020-06-24 |  | 27d |  |  | 99/3/21 | 99/4/4 |
| 174 | 1.9.1.1 | خرید متریال ساپورت و حمل |  | 15d | 2020-06-10 | 2020-06-24 |  | 27d | 0d | start no earlier than 2020-06-10 | 99/3/21 | 99/4/4 |
| 175 | 1.9.2 | **رنگ و سندبلاست** |  | 16d | 2020-06-20 | 2020-07-05 |  | 37d |  |  | 99/3/31 | 99/4/15 |
| 176 | 1.9.2.1 | **لوله** |  | 10d | 2020-06-20 | 2020-06-29 |  | 65d |  |  | 99/3/31 | 99/4/9 |
| 177 | 1.9.2.1.1 | بلاستینگ و رنگ آمیزی لایه 1 لوله ها |  | 10d | 2020-06-20 | 2020-06-29 |  | 65d | 0d | start no earlier than 2020-06-20 | 99/3/31 | 99/4/9 |
| 178 | 1.9.2.2 | **ساپورت** |  | 6d | 2020-06-30 | 2020-07-05 |  | 27d |  |  | 99/4/10 | 99/4/15 |
| 179 | 1.9.2.2.1 | بلاستینگ و رنگ آمیزی ساپورت |  | 3d | 2020-07-03 | 2020-07-05 | 180, 183 | 27d | 0d |  | 99/4/13 | 99/4/15 |
| 180 | 1.9.2.2.2 | رفع پانچ B(REINSTATE) ساپورت |  | 3d | 2020-06-30 | 2020-07-02 | 183 | 27d | 0d |  | 99/4/10 | 99/4/12 |
| 181 | 1.9.3 | **ساخت ساپورت** |  | 15d | 2020-06-25 | 2020-07-09 |  | 27d |  |  | 99/4/5 | 99/4/19 |
| 182 | 1.9.3.1 | ساخت ساپورت ساپورت |  | 3d | 2020-06-25 | 2020-06-27 | 174 | 27d | 0d |  | 99/4/5 | 99/4/7 |
| 183 | 1.9.3.2 | جوشکاری ساپورت |  | 2d | 2020-06-28 | 2020-06-29 | 182 | 27d | 0d |  | 99/4/8 | 99/4/9 |
| 184 | 1.9.3.3 | رفع پانچ و تحویل دهی نهایی ساپورت |  | 4d | 2020-07-06 | 2020-07-09 | 179 | 27d | 1d |  | 99/4/16 | 99/4/19 |
| 185 | 1.9.4 | **اجرای پایپینگ** |  | 43d | 2020-06-30 | 2020-08-11 |  | 26d |  |  | 99/4/10 | 99/5/21 |
| 186 | 1.9.4.1 | تا مرحله فیتاپ |  | 5d | 2020-06-30 | 2020-07-04 | 177 | 65d |  |  | 99/4/10 | 99/4/14 |
| 187 | 1.9.4.2 | تحویل اسلیپر | milestone | 0d | 2020-06-30 | 2020-06-30 |  | 26d | 0d | start no earlier than 2020-06-30 | 99/4/10 | 99/4/10 |
| 188 | 1.9.4.3 | نصب پایپینگ در موقعیت |  | 5d | 2020-06-30 | 2020-07-04 | 187 | 26d | 0d |  | 99/4/10 | 99/4/14 |
| 189 | 1.9.4.4 | جوشکاری پایپینگ |  | 6d | 2020-07-05 | 2020-07-10 | 188 | 26d | 0d |  | 99/4/15 | 99/4/20 |
| 190 | 1.9.4.5 | نصب و تنظیم ساپورت در موقعیت |  | 4d | 2020-07-11 | 2020-07-14 | 184, 189 | 26d | 0d |  | 99/4/21 | 99/4/24 |
| 191 | 1.9.4.6 | جوشکاری و نصب ساپورت در محل |  | 4d | 2020-07-15 | 2020-07-18 | 190 | 26d | 0d |  | 99/4/25 | 99/4/28 |
| 192 | 1.9.4.7 | تست NDT |  | 2d | 2020-07-19 | 2020-07-20 | 191 | 26d | 0d |  | 99/4/29 | 99/4/30 |
| 193 | 1.9.4.8 | رفع پانچ A و LINE CHECK |  | 2d | 2020-07-21 | 2020-07-22 | 192 | 26d | 0d |  | 99/4/31 | 99/5/1 |
| 194 | 1.9.4.9 | هیدروتست،فلاشینگ و DRYING |  | 10d | 2020-07-23 | 2020-08-01 | 193 | 26d | 0d |  | 99/5/2 | 99/5/11 |
| 195 | 1.9.4.10 | REINSTATEMENT |  | 2d | 2020-08-02 | 2020-08-03 | 194 | 26d | 0d |  | 99/5/12 | 99/5/13 |
| 196 | 1.9.4.11 | تاچ آپ رنگ لوله ها بعد از نصب |  | 2d | 2020-08-04 | 2020-08-05 | 195 | 26d | 0d |  | 99/5/14 | 99/5/15 |
| 197 | 1.9.4.12 | رنگ آمیزی لایه های میانی و نهایی |  | 5d | 2020-08-06 | 2020-08-10 | 196 | 26d | 0d |  | 99/5/16 | 99/5/20 |
| 198 | 1.9.4.13 | رفع پانچ B |  | 1d | 2020-08-11 | 2020-08-11 | 197 | 26d | 0d |  | 99/5/21 | 99/5/21 |
| 199 | 1.9.5 | تکمیل مدارک و مستندات |  | 1d | 2020-08-12 | 2020-08-12 | 198 | 26d |  |  | 99/5/22 | 99/5/22 |

| ID | WBS | Task | Type | Duration | Start | Finish | Predecessors | Total slack | Free slack | Constraint | شروع | پایان |
| --- | --- | --- | --- | --- | --- | --- | --- | --- | --- | --- | --- | --- |
| 200 | 1.10 | **بخش LPS** |  | 63d | 2020-06-21 | 2020-08-22 |  | 16d |  |  | 99/4/1 | 99/6/1 |
| 201 | 1.10.1 | **خرید** |  | 15d | 2020-06-21 | 2020-07-05 |  | 16d |  |  | 99/4/1 | 99/4/15 |
| 202 | 1.10.1.1 | خرید متریال ساپورت و حمل |  | 15d | 2020-06-21 | 2020-07-05 |  | 16d | 0d | start no earlier than 2020-06-21 | 99/4/1 | 99/4/15 |
| 203 | 1.10.2 | **رنگ و سندبلاست** |  | 22d | 2020-06-25 | 2020-07-16 |  | 32d |  |  | 99/4/5 | 99/4/26 |
| 204 | 1.10.2.1 | **لوله** |  | 10d | 2020-06-25 | 2020-07-04 |  | 60d |  |  | 99/4/5 | 99/4/14 |
| 205 | 1.10.2.1.1 | بلاستینگ و رنگ آمیزی لایه 1 لوله ها |  | 10d | 2020-06-25 | 2020-07-04 |  | 60d | 0d | start no earlier than 2020-06-25 | 99/4/5 | 99/4/14 |
| 206 | 1.10.2.2 | **ساپورت** |  | 6d | 2020-07-11 | 2020-07-16 |  | 16d |  |  | 99/4/21 | 99/4/26 |
| 207 | 1.10.2.2.1 | بلاستینگ و رنگ آمیزی ساپورت |  | 3d | 2020-07-14 | 2020-07-16 | 208, 211 | 16d | 0d |  | 99/4/24 | 99/4/26 |
| 208 | 1.10.2.2.2 | رفع پانچ B(REINSTATE) ساپورت |  | 3d | 2020-07-11 | 2020-07-13 | 211 | 16d | 0d |  | 99/4/21 | 99/4/23 |
| 209 | 1.10.3 | **ساخت ساپورت** |  | 15d | 2020-07-06 | 2020-07-20 |  | 16d |  |  | 99/4/16 | 99/4/30 |
| 210 | 1.10.3.1 | ساخت ساپورت ساپورت |  | 3d | 2020-07-06 | 2020-07-08 | 202 | 16d | 0d |  | 99/4/16 | 99/4/18 |
| 211 | 1.10.3.2 | جوشکاری ساپورت |  | 2d | 2020-07-09 | 2020-07-10 | 210 | 16d | 0d |  | 99/4/19 | 99/4/20 |
| 212 | 1.10.3.3 | رفع پانچ و تحویل دهی نهایی ساپورت |  | 4d | 2020-07-17 | 2020-07-20 | 207 | 16d | 0d |  | 99/4/27 | 99/4/30 |
| 213 | 1.10.4 | **اجرای پایپینگ** |  | 48d | 2020-07-05 | 2020-08-21 |  | 17d |  |  | 99/4/15 | 99/5/31 |
| 214 | 1.10.4.1 | تا مرحله فیتاپ |  | 5d | 2020-07-05 | 2020-07-09 | 205 | 60d |  |  | 99/4/15 | 99/4/19 |
| 215 | 1.10.4.2 | تحویل اسلیپر | milestone | 0d | 2020-07-05 | 2020-07-05 |  | 21d | 0d | start no earlier than 2020-07-05 | 99/4/15 | 99/4/15 |
| 216 | 1.10.4.3 | نصب پایپینگ در موقعیت |  | 5d | 2020-07-05 | 2020-07-09 | 215 | 21d | 0d |  | 99/4/15 | 99/4/19 |
| 217 | 1.10.4.4 | جوشکاری پایپینگ |  | 6d | 2020-07-10 | 2020-07-15 | 216 | 21d | 5d |  | 99/4/20 | 99/4/25 |
| 218 | 1.10.4.5 | نصب و تنظیم ساپورت در موقعیت |  | 4d | 2020-07-21 | 2020-07-24 | 212, 217 | 16d | 0d |  | 99/4/31 | 99/5/3 |
| 219 | 1.10.4.6 | جوشکاری و نصب ساپورت در محل |  | 4d | 2020-07-25 | 2020-07-28 | 218 | 16d | 0d |  | 99/5/4 | 99/5/7 |
| 220 | 1.10.4.7 | تست NDT |  | 2d | 2020-07-29 | 2020-07-30 | 219 | 16d | 0d |  | 99/5/8 | 99/5/9 |
| 221 | 1.10.4.8 | رفع پانچ A و LINE CHECK |  | 2d | 2020-07-31 | 2020-08-01 | 220 | 16d | 0d |  | 99/5/10 | 99/5/11 |
| 222 | 1.10.4.9 | هیدروتست،فلاشینگ و DRYING |  | 10d | 2020-08-02 | 2020-08-11 | 221 | 16d | 0d |  | 99/5/12 | 99/5/21 |
| 223 | 1.10.4.10 | REINSTATEMENT |  | 2d | 2020-08-12 | 2020-08-13 | 222 | 16d | 0d |  | 99/5/22 | 99/5/23 |
| 224 | 1.10.4.11 | تاچ آپ رنگ لوله ها بعد از نصب |  | 2d | 2020-08-14 | 2020-08-15 | 223 | 16d | 0d |  | 99/5/24 | 99/5/25 |
| 225 | 1.10.4.12 | رنگ آمیزی لایه های میانی و نهایی |  | 5d | 2020-08-16 | 2020-08-20 | 224 | 16d | 0d |  | 99/5/26 | 99/5/30 |
| 226 | 1.10.4.13 | رفع پانچ B |  | 1d | 2020-08-21 | 2020-08-21 | 225 | 16d | 0d |  | 99/5/31 | 99/5/31 |
| 227 | 1.10.5 | تکمیل مدارک و مستندات |  | 1d | 2020-08-22 | 2020-08-22 | 226 | 16d |  |  | 99/6/1 | 99/6/1 |

| ID | WBS | Task | Type | Duration | Start | Finish | Predecessors | Total slack | Free slack | Constraint | شروع | پایان |
| --- | --- | --- | --- | --- | --- | --- | --- | --- | --- | --- | --- | --- |
| 228 | 1.11 | **بخش MEG** |  | 74d | 2020-06-25 | 2020-09-06 |  | 1d |  |  | 99/4/5 | 99/6/16 |
| 229 | 1.11.1 | **خرید** |  | 7d | 2020-07-05 | 2020-07-11 |  | 13d |  |  | 99/4/15 | 99/4/21 |
| 230 | 1.11.1.1 | خرید متریال ساپورت و حمل |  | 7d | 2020-07-05 | 2020-07-11 |  | 13d | 0d | start no earlier than 2020-07-05 | 99/4/15 | 99/4/21 |
| 231 | 1.11.2 | **رنگ و سندبلاست** |  | 28d | 2020-06-25 | 2020-07-22 |  | 35d |  |  | 99/4/5 | 99/5/1 |
| 232 | 1.11.2.1 | **لوله** |  | 7d | 2020-06-25 | 2020-07-01 |  | 63d |  |  | 99/4/5 | 99/4/11 |
| 233 | 1.11.2.1.1 | بلاستینگ و رنگ آمیزی لایه 1 لوله ها |  | 7d | 2020-06-25 | 2020-07-01 |  | 63d | 0d | start no earlier than 2020-06-25 | 99/4/5 | 99/4/11 |
| 234 | 1.11.2.2 | **ساپورت** |  | 6d | 2020-07-17 | 2020-07-22 |  | 13d |  |  | 99/4/27 | 99/5/1 |
| 235 | 1.11.2.2.1 | بلاستینگ و رنگ آمیزی ساپورت |  | 3d | 2020-07-20 | 2020-07-22 | 236, 239 | 13d | 0d |  | 99/4/30 | 99/5/1 |
| 236 | 1.11.2.2.2 | رفع پانچ B(REINSTATE) ساپورت |  | 3d | 2020-07-17 | 2020-07-19 | 239 | 13d | 0d |  | 99/4/27 | 99/4/29 |
| 237 | 1.11.3 | **ساخت ساپورت** |  | 15d | 2020-07-12 | 2020-07-26 |  | 13d |  |  | 99/4/22 | 99/5/5 |
| 238 | 1.11.3.1 | ساخت ساپورت ساپورت |  | 3d | 2020-07-12 | 2020-07-14 | 230 | 13d | 0d |  | 99/4/22 | 99/4/24 |
| 239 | 1.11.3.2 | جوشکاری ساپورت |  | 2d | 2020-07-15 | 2020-07-16 | 238 | 13d | 0d |  | 99/4/25 | 99/4/26 |
| 240 | 1.11.3.3 | رفع پانچ و تحویل دهی نهایی ساپورت |  | 4d | 2020-07-23 | 2020-07-26 | 235 | 13d | 12d |  | 99/5/2 | 99/5/5 |
| 241 | 1.11.4 | **اجرای پایپینگ** |  | 66d | 2020-07-02 | 2020-09-05 |  | 2d |  |  | 99/4/12 | 99/6/15 |
| 242 | 1.11.4.1 | تا مرحله فیتاپ |  | 5d | 2020-07-02 | 2020-07-06 | 233 | 63d |  |  | 99/4/12 | 99/4/16 |
| 243 | 1.11.4.2 | تحویل اسلیپر | milestone | 0d | 2020-07-21 | 2020-07-21 |  | 1d | 0d | start no earlier than 2020-07-21 | 99/4/31 | 99/4/31 |
| 244 | 1.11.4.3 | نصب پایپینگ در موقعیت |  | 10d | 2020-07-21 | 2020-07-30 | 243 | 1d | 0d |  | 99/4/31 | 99/5/9 |
| 245 | 1.11.4.4 | جوشکاری پایپینگ |  | 8d | 2020-07-31 | 2020-08-07 | 244 | 1d | 0d |  | 99/5/10 | 99/5/17 |
| 246 | 1.11.4.5 | نصب و تنظیم ساپورت در موقعیت |  | 4d | 2020-08-08 | 2020-08-11 | 240, 245 | 1d | 0d |  | 99/5/18 | 99/5/21 |
| 247 | 1.11.4.6 | جوشکاری و نصب ساپورت در محل |  | 4d | 2020-08-12 | 2020-08-15 | 246 | 1d | 0d |  | 99/5/22 | 99/5/25 |
| 248 | 1.11.4.7 | تست NDT |  | 2d | 2020-08-16 | 2020-08-17 | 247 | 1d | 0d |  | 99/5/26 | 99/5/27 |
| 249 | 1.11.4.8 | رفع پانچ A و LINE CHECK |  | 2d | 2020-08-18 | 2020-08-19 | 248 | 1d | 0d |  | 99/5/28 | 99/5/29 |
| 250 | 1.11.4.9 | هیدروتست،فلاشینگ و DRYING |  | 7d | 2020-08-20 | 2020-08-26 | 249 | 1d | 0d |  | 99/5/30 | 99/6/5 |
| 251 | 1.11.4.10 | REINSTATEMENT |  | 2d | 2020-08-27 | 2020-08-28 | 250 | 1d | 0d |  | 99/6/6 | 99/6/7 |
| 252 | 1.11.4.11 | تاچ آپ رنگ لوله ها بعد از نصب |  | 2d | 2020-08-29 | 2020-08-30 | 251 | 1d | 0d |  | 99/6/8 | 99/6/9 |
| 253 | 1.11.4.12 | رنگ آمیزی لایه های میانی و نهایی |  | 5d | 2020-08-31 | 2020-09-04 | 252 | 1d | 0d |  | 99/6/10 | 99/6/14 |
| 254 | 1.11.4.13 | رفع پانچ B |  | 1d | 2020-09-05 | 2020-09-05 | 253 | 1d | 0d |  | 99/6/15 | 99/6/15 |
| 255 | 1.11.5 | تکمیل مدارک و مستندات |  | 1d | 2020-09-06 | 2020-09-06 | 254 | 1d |  |  | 99/6/16 | 99/6/16 |

| ID | WBS | Task | Type | Duration | Start | Finish | Predecessors | Total slack | Free slack | Constraint | شروع | پایان |
| --- | --- | --- | --- | --- | --- | --- | --- | --- | --- | --- | --- | --- |
| 256 | 1.12 | **بخش N** |  | 61d | 2020-07-05 | 2020-09-03 |  | 4d |  |  | 99/4/15 | 99/6/13 |
| 257 | 1.12.1 | **خرید** |  | 7d | 2020-07-05 | 2020-07-11 |  | 10d |  |  | 99/4/15 | 99/4/21 |
| 258 | 1.12.1.1 | خرید متریال ساپورت و حمل |  | 7d | 2020-07-05 | 2020-07-11 |  | 10d | 0d | start no earlier than 2020-07-05 | 99/4/15 | 99/4/21 |
| 259 | 1.12.2 | **رنگ و سندبلاست** |  | 14d | 2020-07-17 | 2020-07-30 |  | 10d |  |  | 99/4/27 | 99/5/9 |
| 260 | 1.12.2.1 | **لوله** |  | 10d | 2020-07-21 | 2020-07-30 |  | 34d |  |  | 99/4/31 | 99/5/9 |
| 261 | 1.12.2.1.1 | بلاستینگ و رنگ آمیزی لایه 1 لوله ها |  | 10d | 2020-07-21 | 2020-07-30 |  | 34d | 0d | start no earlier than 2020-07-21 | 99/4/31 | 99/5/9 |
| 262 | 1.12.2.2 | **ساپورت** |  | 7d | 2020-07-17 | 2020-07-23 |  | 9d |  |  | 99/4/27 | 99/5/2 |
| 263 | 1.12.2.2.1 | بلاستینگ و رنگ آمیزی ساپورت |  | 3d | 2020-07-21 | 2020-07-23 | 264, 267 | 9d | 0d | start no earlier than 2020-07-21 | 99/4/31 | 99/5/2 |
| 264 | 1.12.2.2.2 | رفع پانچ B(REINSTATE) ساپورت |  | 3d | 2020-07-17 | 2020-07-19 | 267 | 10d | 1d |  | 99/4/27 | 99/4/29 |
| 265 | 1.12.3 | **ساخت ساپورت** |  | 16d | 2020-07-12 | 2020-07-27 |  | 9d |  |  | 99/4/22 | 99/5/6 |
| 266 | 1.12.3.1 | ساخت ساپورت ساپورت |  | 3d | 2020-07-12 | 2020-07-14 | 258 | 10d | 0d |  | 99/4/22 | 99/4/24 |
| 267 | 1.12.3.2 | جوشکاری ساپورت |  | 2d | 2020-07-15 | 2020-07-16 | 266 | 10d | 0d |  | 99/4/25 | 99/4/26 |
| 268 | 1.12.3.3 | رفع پانچ و تحویل دهی نهایی ساپورت |  | 4d | 2020-07-24 | 2020-07-27 | 263 | 9d | 5d |  | 99/5/3 | 99/5/6 |
| 269 | 1.12.4 | **اجرای پایپینگ** |  | 43d | 2020-07-22 | 2020-09-02 |  | 4d |  |  | 99/5/1 | 99/6/12 |
| 270 | 1.12.4.1 | تا مرحله فیتاپ |  | 5d | 2020-07-31 | 2020-08-04 | 261 | 34d |  |  | 99/5/10 | 99/5/14 |
| 271 | 1.12.4.2 | تحویل اسلیپر | milestone | 0d | 2020-07-22 | 2020-07-22 |  | 4d | 0d | start no earlier than 2020-07-22 | 99/5/1 | 99/5/1 |
| 272 | 1.12.4.3 | نصب پایپینگ در موقعیت |  | 5d | 2020-07-22 | 2020-07-26 | 271 | 4d | 0d |  | 99/5/1 | 99/5/5 |
| 273 | 1.12.4.4 | جوشکاری پایپینگ |  | 6d | 2020-07-27 | 2020-08-01 | 272 | 4d | 0d |  | 99/5/6 | 99/5/11 |
| 274 | 1.12.4.5 | نصب و تنظیم ساپورت در موقعیت |  | 4d | 2020-08-02 | 2020-08-05 | 268, 273 | 4d | 0d |  | 99/5/12 | 99/5/15 |
| 275 | 1.12.4.6 | جوشکاری و نصب ساپورت در محل |  | 4d | 2020-08-06 | 2020-08-09 | 274 | 4d | 0d |  | 99/5/16 | 99/5/19 |
| 276 | 1.12.4.7 | تست NDT |  | 2d | 2020-08-10 | 2020-08-11 | 275 | 4d | 0d |  | 99/5/20 | 99/5/21 |
| 277 | 1.12.4.8 | رفع پانچ A و LINE CHECK |  | 2d | 2020-08-12 | 2020-08-13 | 276 | 4d | 0d |  | 99/5/22 | 99/5/23 |
| 278 | 1.12.4.9 | هیدروتست،فلاشینگ و DRYING |  | 10d | 2020-08-14 | 2020-08-23 | 277 | 4d | 0d |  | 99/5/24 | 99/6/2 |
| 279 | 1.12.4.10 | REINSTATEMENT |  | 2d | 2020-08-24 | 2020-08-25 | 278 | 4d | 0d |  | 99/6/3 | 99/6/4 |
| 280 | 1.12.4.11 | تاچ آپ رنگ لوله ها بعد از نصب |  | 2d | 2020-08-26 | 2020-08-27 | 279 | 4d | 0d |  | 99/6/5 | 99/6/6 |
| 281 | 1.12.4.12 | رنگ آمیزی لایه های میانی و نهایی |  | 5d | 2020-08-28 | 2020-09-01 | 280 | 4d | 0d |  | 99/6/7 | 99/6/11 |
| 282 | 1.12.4.13 | رفع پانچ B |  | 1d | 2020-09-02 | 2020-09-02 | 281 | 4d | 0d |  | 99/6/12 | 99/6/12 |
| 283 | 1.12.5 | تکمیل مدارک و مستندات |  | 1d | 2020-09-03 | 2020-09-03 | 282 | 4d |  |  | 99/6/13 | 99/6/13 |

| ID | WBS | Task | Type | Duration | Start | Finish | Predecessors | Total slack | Free slack | Constraint | شروع | پایان |
| --- | --- | --- | --- | --- | --- | --- | --- | --- | --- | --- | --- | --- |
| 284 | 1.13 | **بخش GALVANIZED** |  | 51d | 2020-07-12 | 2020-08-31 |  | 7d |  |  | 99/4/22 | 99/6/10 |
| 285 | 1.13.1 | **خرید** |  | 7d | 2020-07-12 | 2020-07-18 |  | 7d |  |  | 99/4/22 | 99/4/28 |
| 286 | 1.13.1.1 | خرید متریال ساپورت و حمل |  | 7d | 2020-07-12 | 2020-07-18 |  | 7d | 0d | start no earlier than 2020-07-12 | 99/4/22 | 99/4/28 |
| 287 | 1.13.2 | **رنگ و سندبلاست** |  | 8d | 2020-07-22 | 2020-07-29 |  | 9d |  |  | 99/5/1 | 99/5/8 |
| 288 | 1.13.2.1 | **لوله** |  | 7d | 2020-07-22 | 2020-07-28 |  | 36d |  |  | 99/5/1 | 99/5/7 |
| 289 | 1.13.2.1.1 | بلاستینگ و رنگ آمیزی لایه 1 لوله ها |  | 7d | 2020-07-22 | 2020-07-28 |  | 36d | 0d | start no earlier than 2020-07-22 | 99/5/1 | 99/5/7 |
| 290 | 1.13.2.2 | **ساپورت** |  | 6d | 2020-07-24 | 2020-07-29 |  | 7d |  |  | 99/5/3 | 99/5/8 |
| 291 | 1.13.2.2.1 | بلاستینگ و رنگ آمیزی ساپورت |  | 3d | 2020-07-27 | 2020-07-29 | 292, 295 | 7d | 0d | start no earlier than 2020-07-21 | 99/5/6 | 99/5/8 |
| 292 | 1.13.2.2.2 | رفع پانچ B(REINSTATE) ساپورت |  | 3d | 2020-07-24 | 2020-07-26 | 295 | 7d | 0d |  | 99/5/3 | 99/5/5 |
| 293 | 1.13.3 | **ساخت ساپورت** |  | 15d | 2020-07-19 | 2020-08-02 |  | 7d |  |  | 99/4/29 | 99/5/12 |
| 294 | 1.13.3.1 | ساخت ساپورت ساپورت |  | 3d | 2020-07-19 | 2020-07-21 | 286 | 7d | 0d |  | 99/4/29 | 99/4/31 |
| 295 | 1.13.3.2 | جوشکاری ساپورت |  | 2d | 2020-07-22 | 2020-07-23 | 294 | 7d | 0d |  | 99/5/1 | 99/5/2 |
| 296 | 1.13.3.3 | رفع پانچ و تحویل دهی نهایی ساپورت |  | 4d | 2020-07-30 | 2020-08-02 | 291 | 7d | 0d |  | 99/5/9 | 99/5/12 |
| 297 | 1.13.4 | **اجرای پایپینگ** |  | 40d | 2020-07-22 | 2020-08-30 |  | 8d |  |  | 99/5/1 | 99/6/9 |
| 298 | 1.13.4.1 | تا مرحله فیتاپ |  | 5d | 2020-07-29 | 2020-08-02 | 289 | 36d |  |  | 99/5/8 | 99/5/12 |
| 299 | 1.13.4.2 | تحویل اسلیپر | milestone | 0d | 2020-07-22 | 2020-07-22 |  | 8d | 0d | start no earlier than 2020-07-22 | 99/5/1 | 99/5/1 |
| 300 | 1.13.4.3 | نصب پایپینگ در موقعیت |  | 5d | 2020-07-22 | 2020-07-26 | 299 | 8d | 0d |  | 99/5/1 | 99/5/5 |
| 301 | 1.13.4.4 | جوشکاری پایپینگ |  | 6d | 2020-07-27 | 2020-08-01 | 300 | 8d | 1d |  | 99/5/6 | 99/5/11 |
| 302 | 1.13.4.5 | نصب و تنظیم ساپورت در موقعیت |  | 3d | 2020-08-03 | 2020-08-05 | 296, 301 | 7d | 0d |  | 99/5/13 | 99/5/15 |
| 303 | 1.13.4.6 | جوشکاری و نصب ساپورت در محل |  | 4d | 2020-08-06 | 2020-08-09 | 302 | 7d | 0d |  | 99/5/16 | 99/5/19 |
| 304 | 1.13.4.7 | تست NDT |  | 2d | 2020-08-10 | 2020-08-11 | 303 | 7d | 0d |  | 99/5/20 | 99/5/21 |
| 305 | 1.13.4.8 | رفع پانچ A و LINE CHECK |  | 2d | 2020-08-12 | 2020-08-13 | 304 | 7d | 0d |  | 99/5/22 | 99/5/23 |
| 306 | 1.13.4.9 | هیدروتست،فلاشینگ و DRYING |  | 7d | 2020-08-14 | 2020-08-20 | 305 | 7d | 0d |  | 99/5/24 | 99/5/30 |
| 307 | 1.13.4.10 | REINSTATEMENT |  | 2d | 2020-08-21 | 2020-08-22 | 306 | 7d | 0d |  | 99/5/31 | 99/6/1 |
| 308 | 1.13.4.11 | تاچ آپ رنگ لوله ها بعد از نصب |  | 2d | 2020-08-23 | 2020-08-24 | 307 | 7d | 0d |  | 99/6/2 | 99/6/3 |
| 309 | 1.13.4.12 | رنگ آمیزی لایه های میانی و نهایی |  | 5d | 2020-08-25 | 2020-08-29 | 308 | 7d | 0d |  | 99/6/4 | 99/6/8 |
| 310 | 1.13.4.13 | رفع پانچ B |  | 1d | 2020-08-30 | 2020-08-30 | 309 | 7d | 0d |  | 99/6/9 | 99/6/9 |
| 311 | 1.13.5 | تکمیل مدارک و مستندات |  | 1d | 2020-08-31 | 2020-08-31 | 310 | 7d |  |  | 99/6/10 | 99/6/10 |

| ID | WBS | Task | Type | Duration | Start | Finish | Predecessors | Total slack | Free slack | Constraint | شروع | پایان |
| --- | --- | --- | --- | --- | --- | --- | --- | --- | --- | --- | --- | --- |
| 312 | 1.14 | **بخش STAINLESS STEEL** |  | 129d | 2020-05-02 | 2020-09-07 |  | 0d |  |  | 99/2/13 | 99/6/17 |
| 313 | 1.14.1 | **خرید** |  | 15d | 2020-07-05 | 2020-07-19 |  | 2d |  |  | 99/4/15 | 99/4/29 |
| 314 | 1.14.1.1 | خرید متریال ساپورت و حمل |  | 15d | 2020-07-05 | 2020-07-19 |  | 2d | 0d | start no earlier than 2020-07-05 | 99/4/15 | 99/4/29 |
| 315 | 1.14.2 | **رنگ و سندبلاست** |  | 10d | 2020-07-22 | 2020-07-31 |  | 5d |  |  | 99/5/1 | 99/5/10 |
| 316 | 1.14.2.1 | **لوله** |  | 10d | 2020-07-22 | 2020-07-31 |  | 38d |  |  | 99/5/1 | 99/5/10 |
| 317 | 1.14.2.1.1 | بلاستینگ و رنگ آمیزی لایه 1 لوله ها |  | 10d | 2020-07-22 | 2020-07-31 |  | 38d |  | start no earlier than 2020-07-22 | 99/5/1 | 99/5/10 |
| 318 | 1.14.2.2 | **ساپورت** |  | 6d | 2020-07-25 | 2020-07-30 |  | 2d |  |  | 99/5/4 | 99/5/9 |
| 319 | 1.14.2.2.1 | بلاستینگ و رنگ آمیزی ساپورت |  | 3d | 2020-07-28 | 2020-07-30 | 320, 323 | 2d | 0d | start no earlier than 2020-07-21 | 99/5/7 | 99/5/9 |
| 320 | 1.14.2.2.2 | رفع پانچ B(REINSTATE) ساپورت |  | 3d | 2020-07-25 | 2020-07-27 | 323 | 2d | 0d |  | 99/5/4 | 99/5/6 |
| 321 | 1.14.3 | **ساخت ساپورت** |  | 15d | 2020-07-20 | 2020-08-03 |  | 2d |  |  | 99/4/30 | 99/5/13 |
| 322 | 1.14.3.1 | ساخت ساپورت ساپورت |  | 3d | 2020-07-20 | 2020-07-22 | 314 | 2d | 0d |  | 99/4/30 | 99/5/1 |
| 323 | 1.14.3.2 | جوشکاری ساپورت |  | 2d | 2020-07-23 | 2020-07-24 | 322 | 2d | 0d |  | 99/5/2 | 99/5/3 |
| 324 | 1.14.3.3 | رفع پانچ و تحویل دهی نهایی ساپورت |  | 4d | 2020-07-31 | 2020-08-03 | 319 | 2d |  |  | 99/5/10 | 99/5/13 |
| 325 | 1.14.4 | **اجرای پایپینگ** |  | 128d | 2020-05-02 | 2020-09-06 |  | 1d |  |  | 99/2/13 | 99/6/16 |
| 326 | 1.14.4.1 | تا مرحله فیتاپ |  | 7d | 2020-05-02 | 2020-05-08 |  | 122d |  |  | 99/2/13 | 99/2/19 |
| 327 | 1.14.4.2 | تحویل اسلیپر | milestone | 0d | 2020-07-22 | 2020-07-22 |  | 0d |  | start no earlier than 2020-07-22 | 99/5/1 | 99/5/1 |
| 328 | 1.14.4.3 | نصب پایپینگ در موقعیت |  | 8d | 2020-07-22 | 2020-07-29 | 327 | 0d |  |  | 99/5/1 | 99/5/8 |
| 329 | 1.14.4.4 | جوشکاری پایپینگ |  | 7d | 2020-07-30 | 2020-08-05 | 328 | 0d |  |  | 99/5/9 | 99/5/15 |
| 330 | 1.14.4.5 | نصب و تنظیم ساپورت در موقعیت |  | 4d | 2020-08-06 | 2020-08-09 | 324, 329 | 0d |  |  | 99/5/16 | 99/5/19 |
| 331 | 1.14.4.6 | جوشکاری و نصب ساپورت در محل |  | 4d | 2020-08-10 | 2020-08-13 | 330 | 0d |  |  | 99/5/20 | 99/5/23 |
| 332 | 1.14.4.7 | تست NDT |  | 2d | 2020-08-14 | 2020-08-15 | 331 | 0d |  |  | 99/5/24 | 99/5/25 |
| 333 | 1.14.4.8 | رفع پانچ A و LINE CHECK |  | 2d | 2020-08-16 | 2020-08-17 | 332 | 0d |  |  | 99/5/26 | 99/5/27 |
| 334 | 1.14.4.9 | هیدروتست،فلاشینگ و DRYING |  | 10d | 2020-08-18 | 2020-08-27 | 333 | 0d |  |  | 99/5/28 | 99/6/6 |
| 335 | 1.14.4.10 | REINSTATEMENT |  | 2d | 2020-08-28 | 2020-08-29 | 334 | 0d |  |  | 99/6/7 | 99/6/8 |
| 336 | 1.14.4.11 | تاچ آپ رنگ لوله ها بعد از نصب |  | 2d | 2020-08-30 | 2020-08-31 | 335 | 0d |  |  | 99/6/9 | 99/6/10 |
| 337 | 1.14.4.12 | رنگ آمیزی لایه های میانی و نهایی |  | 5d | 2020-09-01 | 2020-09-05 | 336 | 0d |  |  | 99/6/11 | 99/6/15 |
| 338 | 1.14.4.13 | رفع پانچ B |  | 1d | 2020-09-06 | 2020-09-06 | 337 | 0d |  |  | 99/6/16 | 99/6/16 |
| 339 | 1.14.5 | تکمیل مدارک و مستندات |  | 1d | 2020-09-07 | 2020-09-07 | 338 | 0d |  |  | 99/6/17 | 99/6/17 |

| ID | WBS | Task | Duration | Start | Finish | Total slack | Constraint | شروع | پایان |
| --- | --- | --- | --- | --- | --- | --- | --- | --- | --- |
| 340 | 1.15 | **بخش U/G (PE)** | 39d | 2020-06-21 | 2020-07-29 | 40d |  | 99/4/1 | 99/5/8 |
| 341 | 1.15.1 | **اجرای پایپینگ** | 36d | 2020-06-21 | 2020-07-26 | 43d |  | 99/4/1 | 99/5/5 |
| 342 | 1.15.1.1 | آماده سازی سطح کانال | 5d | 2020-06-21 | 2020-06-25 | 74d | start no earlier than 2020-06-21 | 99/4/1 | 99/4/5 |
| 343 | 1.15.1.2 | حمل لوله به محل ، نصب در کانال | 3d | 2020-06-26 | 2020-06-28 | 71d | start no earlier than 2020-06-26 | 99/4/6 | 99/4/8 |
| 344 | 1.15.1.3 | جوشکاری | 14d | 2020-06-29 | 2020-07-12 | 57d | start no earlier than 2020-06-29 | 99/4/9 | 99/4/22 |
| 345 | 1.15.1.4 | رفع پانچ A و LINE CHECK | 4d | 2020-07-13 | 2020-07-16 | 53d | start no earlier than 2020-07-13 | 99/4/23 | 99/4/26 |
| 346 | 1.15.1.5 | هیدروتست | 10d | 2020-07-17 | 2020-07-26 | 43d | start no earlier than 2020-07-17 | 99/4/27 | 99/5/5 |
| 347 | 1.15.2 | تکمیل مدارک و مستندات | 3d | 2020-07-27 | 2020-07-29 | 40d | start no earlier than 2020-07-27 | 99/5/6 | 99/5/8 |
